# Projekt_jo02

Schedule from MS Project, 2008-08-08 to 2008-09-19, costs in Ft.
iqjb

## Calendars

- Szabványos: Mon-Fri 08:00-12:00, 13:00-17:00; Sat-Sun off.

## Resources

| Resource | Unit | Rate |
| --- | --- | --- |
| Á hálózatépítő 1 |  | 1500 |
| Á műszaki informatikus 1 |  | 1500 |
| Á adminisztrátor 1 |  | 1000 |
| Kovács Anita |  | 6000 |
| Kiss Attila |  | 10000 |
| Nagy Annamária |  |  |
| Paál Anikó |  |  |
| Kiss Anett |  | 800 |
| Rétlaki Géza |  | 1400 |
| Mároki Teréz |  | 1400 |
| Mosolygó Ferenc |  | 1600 |
| Téglás Csaba |  | 1200 |
| Podorek Paula |  | 800 |
| Tiefenghalter Eszter |  | 1200 |
| Szakócza István |  | 1700 |
| Késmárki Lilla |  | 1500 |
| Á hálózatépítő 2 |  | 1500 |
| Á műszaki informatikus 2 |  | 1500 |
| Á adminisztrátor 2 |  | 1000 |
| Á műszaki informatikus 3 |  | 1500 |
| Á adminisztrátor 3 |  | 1000 |
| Á adminisztrátor 4 |  | 1000 |
| Számítógép beszerzési költségek | eFt | 1000 |
| Hálózatépítés költségei | eFt | 1000 |
| Egyéb költségek | eFt | 1000 |
| Szoftverköltségek | eFt | 1000 |

## Schedule

| ID | WBS | Task | Type | Duration | Start | Finish | Predecessors | Total slack | Resources | Work | Cost | Text29 | Text30 |
| --- | --- | --- | --- | --- | --- | --- | --- | --- | --- | --- | --- | --- | --- |
| 1 | 1 | **előkészítés** |  | 20d | 2008-08-08 | 2008-09-04 |  | 0d |  | 156h | 406,000 | 480 | 20 n |
| 2 | 1.1 | igények felmérése |  | 20d | 2008-08-08 | 2008-09-04 |  | 10.5d |  |  |  | 480 | 20 n |
| 3 | 1.2 | igények kiértékelése |  | 4d | 2008-08-08 | 2008-08-13 |  | 0d |  |  |  | 480 | 4 n |
| 4 | 1.3 | megoldási lehetőségek kidolgozása |  | 3d | 2008-08-14 | 2008-08-18 | 3 | 0d | Á műszaki informatikus 1; Á adminisztrátor 4; Á műszaki informatikus 2 | 72h | 96,000 | 480 | 3 n |
| 5 | 1.4 | megoldási dokumentumok elfogadása | milestone | 0d | 2008-08-18 | 2008-08-18 | 4 | 0d | Kiss Attila |  |  | 480 | --mérföldkő-- |
| 6 | 1.5 | megoldási lehetőségek ismertetése |  | 4h | 2008-08-20 | 2008-08-20 | 5FS+1d | 0d | Kovács Anita; Paál Anikó; Kiss Attila; Nagy Annamária; Á műszaki informatikus 1 | 20h | 70,000 | 480 | 4 ó |
| 7 | 1.6 | döntés a megvalósítandó lehetőségről | milestone | 0d | 2008-08-20 | 2008-08-20 | 6 | 0d | Nagy Annamária |  |  | 480 | --mérföldkő-- |
| 8 | 1.7 | részletes terv kidolgozása |  | 4d | 2008-08-20 | 2008-08-26 | 7 | 0d | Kovács Anita; Á műszaki informatikus 1 [50%]; Á hálózatépítő 1 [50%] | 64h | 240,000 | 480 | 4 n |
| 9 | 1.8 | terv elfogadtatása | milestone | 0d | 2008-08-26 | 2008-08-26 | 8 | 0d | Kiss Attila; Nagy Annamária |  |  | 480 | --mérföldkő-- |
| 10 | 2 | **megvalósítás A terv I. szakasz** |  | 22d | 2008-08-20 | 2008-09-19 |  | 0d |  | 311h | 27,266,500 | 480 | 22 n |
| 11 | 2.1 | hitelkeret megérkezik | milestone | 0d | 2008-08-20 | 2008-08-20 | 7 | 4d |  |  |  | 480 | --mérföldkő-- |
| 12 | 2.2 | szerverek beszerzzése |  | 4d | 2008-08-26 | 2008-09-01 | 9, 11 | 0d | Számítógép beszerzési költségek [20000 eFt] |  | 20,000,000 | 480 | 4 n |
| 13 | 2.3 | szerverek összeszerelése |  | 2d | 2008-09-01 | 2008-09-03 | 12 | 0d | Á műszaki informatikus 2 | 16h | 24,000 | 480 | 2 n |
| 14 | 2.4 | szerver installálása, inicializálása |  | 6d | 2008-09-03 | 2008-09-11 | 13 | 0d | Á műszaki informatikus 1; Á műszaki informatikus 2; Szoftverköltségek [2500 eFt] | 96h | 2,644,000 | 480 | 6 n |
| 15 | 2.5 | kábelezés, kliensgépek csatlakoztatása |  | 4d | 2008-09-01 | 2008-09-05 | 12 | 4d | Á hálózatépítő 1; Á hálózatépítő 2; Hálózatépítés költségei [800 eFt] | 55h | 882,500 | 480 | 4 n |
| 16 | 2.6 | kliensgépek installálása, inicializálása |  | 6d | 2008-09-11 | 2008-09-19 | 15, 14 | 0d | Á műszaki informatikus 1; Á műszaki informatikus 2; Á műszaki informatikus 3; Szoftverköltségek [3500 eFt] | 144h | 3,716,000 | 480 | 6 n |
| 17 | 2.7 | hálózatkiépítés kész | milestone | 0d | 2008-09-19 | 2008-09-19 | 16 | 0d |  |  |  | 480 | --mérföldkő-- |

Notes:
- 12: legalább 64 magos processzorra van szükség
