# Projekt_jo_02_03

Schedule from MS Project, 2008-10-27 to 2008-11-20, status date 2008-11-07, costs in Ft.
iqjb

## Calendars

- Szabványos: Mon-Fri 08:00-12:00, 13:00-17:00; Sat-Sun off.

## Resources

| Resource | Unit | Rate |
| --- | --- | --- |
| Á hálózatépítő 1 |  | 1500 |
| Á műszaki informatikus 1 |  | 1500 |
| Á adminisztrátor 1 |  | 1000 |
| Kovács Anita |  | 6000 |
| Kiss Attila |  | 10000 |
| Nagy Annamária |  | 1200 |
| Paál Anikó |  | 1300 |
| Kőbán Péter |  | 4200 |
| Rétlaki Géza |  | 4400 |
| Mároki Teréz |  | 1400 |
| Mosolygó Ferenc |  | 4100 |
| Téglás Csaba |  | 1200 |
| Podorek Paula |  | 4100 |
| Tiefenghalter Eszter |  | 1200 |
| Szakócza István |  | 3900 |
| Késmárki Lilla |  | 4000 |
| Á hálózatépítő 2 |  | 1500 |
| Á műszaki informatikus 2 |  | 1500 |
| Á adminisztrátor 2 |  | 1000 |
| Á műszaki informatikus 3 |  | 1500 |
| Á adminisztrátor 3 |  | 1000 |
| Á adminisztrátor 4 |  | 1000 |
| Számítógép beszerzési költségek | eFt | 1000 |
| Hálózatépítés költségei | eFt | 1000 |
| Szoftverköltségek | eFt | 1000 |
| Á programozó 3 |  | 4500 |
| Á programozó 4 |  | 4500 |
| Á_projektszponzor |  | 8000 |
| Á oktató 1 |  | 4000 |
| Á oktató 2 |  | 4000 |
| Á oktató 3 |  | 4000 |
| Á műszaki informatikus 4 |  | 1500 |
| Kő Pál |  | 1200 |
| Kiss Irén |  | 1200 |
| Nagy Armand |  | 1200 |
| Beke Botond |  | 1200 |
| Kőváry Laura |  | 1200 |
| Kőpataki Tihamér |  | 2100 |
| Baumgartner Karina |  |  |
| Mathiugasz Gitisz |  | 6000 |
| Oktatók |  |  |
| Műszaki szakemberek |  |  |
| Telepítési csoport |  |  |
| Á programozó 1 |  | 4500 |
| Á programozó 2 |  | 4500 |
| Á_projektmenedzser |  | 6000 |
| Á megbízó koordinátor 1 |  | 2500 |
| Á megbízó koordinátor 2 |  | 2500 |
| Kiss Edit |  | 7000 |
| Molnár Noémi |  | 7000 |
| Nyári Éva |  | 2500 |
| Botond Építő Kft. |  |  |
| Megbízási díj | eFt | 1000 |
| Á_rendszergazda 1 |  | 3000 |
| Á_rendszergazda 2 |  | 3000 |
| Á_rendszergazda 3 |  | 3000 |
| Á_rendszergazda 4 |  | 3000 |
| Megbízási díj | eFt | 1000 |

## Schedule

| ID | WBS | Task | Type | Duration | Start | Finish | Predecessors | Total slack | Free slack | Resources | Work | Cost | Text29 | Text30 |
| --- | --- | --- | --- | --- | --- | --- | --- | --- | --- | --- | --- | --- | --- | --- |
| 1 | 1 | szerkezetépítés kész | milestone | 0d | 2008-10-27 | 2008-10-27 |  | 18.5d |  |  |  |  | 480 | --mérföldkő-- |
| 2 | 2 | **befejező munkálatok** |  | 18.5d | 2008-10-27 | 2008-11-20 |  | 0d |  |  | 336h | 22,585,200 | 480 | 18 n, 4 ó |
| 3 | 2.1 | gk burkolat építése |  | 6d | 2008-10-27 | 2008-11-03 |  | 0d |  | Botond Építő Kft.; Megbízási díj [360 eFt] | 48h | 360,000 | 480 | 6 n |
| 4 | 2.2 | szerverszobák glettelése |  | 2d | 2008-10-29 | 2008-10-30 | 3SS+2d | 0d |  | Botond Építő Kft.; Megbízási díj [1200 eFt] | 16h | 1,200,000 | 480 | 2 n |
| 5 | 2.3 | szerverszobák festése |  | 2d | 2008-10-31 | 2008-11-03 | 4 | 0d |  | Botond Építő Kft.; Megbízási díj [850 eFt] | 16h | 850,000 | 480 | 2 n |
| 6 | 2.4 | száradási idő |  | 2ed | 2008-11-03 | 2008-11-05 | 5 | 1.88d |  |  |  |  | 480 | 6 n |
| 7 | 2.5 | szerverek leszállítása |  | 1d | 2008-11-06 | 2008-11-06 | 6, 3 | 0d |  | Számítógép beszerzési költségek [16000 eFt] |  | 16,000,000 | 480 | 1 n |
| 8 | 2.6 | szerverek elhelyezése |  | 2d | 2008-11-06 | 2008-11-10 | 7FS-0.5d | 0d |  | Á műszaki informatikus 1; Á műszaki informatikus 2 | 32h | 48,000 | 480 | 2 n |
| 9 | 2.7 | 1. szerver installálása |  | 2d | 2008-11-10 | 2008-11-12 | 8 | 0d |  | Nagy Annamária; Podorek Paula | 32h | 84,800 | 480 | 2 n |
| 10 | 2.8 | 2. szerver installálása |  | 3d | 2008-11-10 | 2008-11-13 | 8 | 2d |  | Paál Anikó; Á_rendszergazda 4 | 48h | 103,200 | 480 | 3 n |
| 11 | 2.9 | 3. szerver installálása I. |  | 1d | 2008-11-10 | 2008-11-11 | 8 | 3d | 0d | Nagy Annamária; Podorek Paula | 16h | 42,400 | 480 | 1 n |
| 12 | 2.10 | 3. szerver installálása II. |  | 1d | 2008-11-11 | 2008-11-12 | 11 | 3d |  | Nagy Annamária; Podorek Paula | 16h | 42,400 | 480 | 1 n |
| 13 | 2.11 | kliensgépek leszállítása |  | 1d | 2008-11-06 | 2008-11-07 | 8SS | 3d |  | Számítógép beszerzési költségek [3600 eFt] |  | 3,600,000 | 480 | 1 n |
| 14 | 2.12 | kliensgépek installálása |  | 4d | 2008-11-12 | 2008-11-18 | 9, 13 | 0d |  | Nagy Annamária; Podorek Paula | 64h | 169,600 | 480 | 4 n |
| 15 | 2.13 | szerver és kliensprogramok inicializálása |  | 2d | 2008-11-17 | 2008-11-19 | 9, 10, 14FS-1d, 12 | 0d |  | Paál Anikó; Á_rendszergazda 4 | 32h | 68,800 | 480 | 2 n |
| 16 | 2.14 | beállítások, kapcsolatok tesztelése |  | 1d | 2008-11-19 | 2008-11-20 | 15 | 0d |  | Á adminisztrátor 1; Á adminisztrátor 2 | 16h | 16,000 | 480 | 1 n |
| 17 | 2.15 | installálás, inicializálás kész | milestone | 0d | 2008-11-20 | 2008-11-20 | 16 | 0d |  |  |  |  | 480 | --mérföldkő-- |
