# Projekt_jo_02_03

Schedule from MS Project, 2009-04-15 to 2009-09-01, costs in Ft.
iqjb

## Calendars

- Szabványos: Mon-Fri 08:00-12:00, 13:00-17:00; Sat-Sun off.

## Resources

| Resource | Rate |
| --- | --- |
| Á programozó 1 | 4500 |
| Á programozó 2 | 4500 |
| Á programozó 3 | 4500 |
| Á programozó 4 | 4500 |
| Á programozó 5 | 4500 |
| Á programozó 6 | 4500 |
| Kiss Anett | 3500 |
| Nagy Lajos | 4400 |
| Rizs Ottó | 5000 |
| Nagy Anita | 4600 |
| Kurtán Lajos | 2000 |
| Hermencz Béla | 4500 |
| Á hálózatépítő 1 | 2500 |
| Á hálózatépítő 2 | 2500 |
| Á hálózatépítő 3 | 2500 |
| Á hálózatépítő 4 | 2500 |
| Zorek Anna | 2400 |
| Tomory Pál | 2800 |
| Zách Felicián | 2300 |
| Kincses Éva | 2500 |
| Á adminisztrátor 1 | 2000 |
| Á adminisztrátor 2 | 2000 |
| Á adminisztrátor 3 | 2000 |
| Á adminisztrátor 4 | 2000 |
| Kiss Irén | 1000 |
| Braun Éva | 2000 |
| Lakner Pál | 1600 |
| Polnauer Erika | 2000 |
| Á rendszergazda 1 | 3500 |
| Á rendszergazda 2 | 3500 |
| Ney Károly | 3500 |
| Kochen Zoltán | 3700 |
| Ktg. EUR-ban | 283 |
| Ktg. USD-ban | 210 |
| Á villamosmérnök 1 | 4500 |
| Á villamosmérnök 2 | 4500 |
| Á villamosmérnök 3 | 4500 |
| Simonyi Károly | 5200 |
| Csizek Éva | 4200 |
| Pálfalai Péter | 3800 |
| Godrobán Emese | 2000 |
| Á adatbázistervező 1 | 4500 |
| Á adatbázistervező 2 | 4500 |
| Pocsonkai Pál | 4500 |
| Á műszaki informatikus 1 | 2000 |
| Á műszaki informatikus 2 | 2000 |
| Beke István | 2000 |
| Ney Katalin | 1900 |
| Á szponzor | 10000 |
| Piros Anita | 2300 |
| szoftverktg. USD-ban | 220 |
| Á műszaki informatikus 3 | 2000 |

## Schedule

| ID | WBS | Task | Type | Duration | Start | Finish | Predecessors | Total slack | Free slack | Constraint | Resources | Work | Cost | Text29 | Text30 |
| --- | --- | --- | --- | --- | --- | --- | --- | --- | --- | --- | --- | --- | --- | --- | --- |
| 1 | S2-2008-ETV | **Előtervezés** |  | 23.5d | 2009-04-15 | 2009-05-18 |  | 0d |  |  |  | 520h | 1,369,200 | 480 | 23 n, 4 ó |
| 2 | S2-2008-ETV.mbin | indító megbeszélés |  | 4h | 2009-04-15 | 2009-04-15 |  | 0d |  |  | Á adatbázistervező 1; Á adatbázistervező 2; Á adminisztrátor 1; Á hálózatépítő 1; Á műszaki informatikus 1; Á műszaki informatikus 2; Hermencz Béla; Á programozó 2; Á programozó 3; Á rendszergazda 1; Á villamosmérnök 1; Piros Anita | 48h | 165,200 | 480 | 4 ó |
| 3 | S2-2008-ETV.mhpr | paraméterek meghatározása |  | 1d | 2009-04-16 | 2009-04-16 | 2 | 0d |  |  | Á műszaki informatikus 1; Á adatbázistervező 1; Hermencz Béla | 24h | 88,000 | 480 | 1 n |
| 4 | S2-2008-ETV.öisz | igényfelmérő, szintfelmérő kérdések összeállítása |  | 3d | 2009-04-17 | 2009-04-21 | 3 | 0d |  |  | Á műszaki informatikus 1; Á műszaki informatikus 2 | 48h | 96,000 | 480 | 3 n |
| 5 | S2-2008-ETV.iisz | igényfelmérő, szintfelmérő szoftver inicializálása |  | 2d | 2009-04-22 | 2009-04-23 | 4 | 0d |  |  | Hermencz Béla | 16h | 72,000 | 480 | 2 n |
| 6 | S2-2008-ETV.visz | igényfelmérés, szintfelmérés |  | 12d | 2009-04-24 | 2009-05-11 | 5 | 0d |  |  | Á adminisztrátor 1; Á adminisztrátor 2; Á műszaki informatikus 1 [50%] | 240h | 480,000 | 480 | 12 n |
| 7 | S2-2008-ETV.kisz | kiértékelés |  | 6d | 2009-05-06 | 2009-05-13 | 6SS+8d | 0d |  |  | Á műszaki informatikus 1 [50%]; Á műszaki informatikus 2 | 72h | 144,000 | 480 | 6 n |
| 8 | S2-2008-ETV.jvkd | javaslatok kidolgozása |  | 2d | 2009-05-14 | 2009-05-15 | 7, 6 | 0d |  |  | Á adatbázistervező 1; Hermencz Béla; Á villamosmérnök 1 | 48h | 216,000 | 480 | 2 n |
| 9 | S2-2008-ETV.disz | döntés a továbblépésről | milestone | 0d | 2009-05-15 | 2009-05-15 | 8 | 0d |  |  | Á szponzor |  |  | 480 | --mérföldkő-- |
| 10 | S2-2008-ETV.mhtv | tervezési paraméterek meghatározása |  | 1d | 2009-05-18 | 2009-05-18 | 9 | 0d |  |  | Á adatbázistervező 1; Hermencz Béla; Á villamosmérnök 1 | 24h | 108,000 | 480 | 1 n |
| 11 | S2-2008-TVS | **Tervezés** |  | 12.5d | 2009-05-19 | 2009-06-04 |  | 0d |  |  |  | 388h | 1,692,000 | 480 | 12 n, 4 ó |
| 12 | S2-2008-TVS.átvp | tervezési paraméterek átvétele |  | 4h | 2009-05-19 | 2009-05-19 | 10 | 0d |  |  | Á adatbázistervező 1; Á adatbázistervező 2; Hermencz Béla; Á programozó 2; Á programozó 3; Á villamosmérnök 1 | 24h | 108,000 | 480 | 4 ó |
| 13 | S2-2008-TVS.eatv | adatbázisterv elkészítése |  | 6d | 2009-05-19 | 2009-05-27 | 12 | 4d | 0d |  | Á adatbázistervező 1; Á adatbázistervező 2; Á műszaki informatikus 1 [25%] | 108h | 456,000 | 480 | 6 n |
| 14 | S2-2008-TVS.katv | adatbázisterv kész | milestone | 0d | 2009-05-27 | 2009-05-27 | 13 | 6d |  |  |  |  |  | 480 | --mérföldkő-- |
| 15 | S2-2008-TVS.bszv | szükséges szoftverek beszerzése |  | 1d | 2009-05-19 | 2009-05-20 | 12 | 0d |  |  | Á műszaki informatikus 1 | 8h | 16,000 | 480 | 1 n |
| 16 | S2-2008-TVS.iszv | szoftverek inicializálása |  | 1d | 2009-05-20 | 2009-05-21 | 15 | 0d |  |  | Hermencz Béla [50%]; Á rendszergazda 1 [50%] | 8h | 32,000 | 480 | 1 n |
| 17 | S2-2008-TVS.eptv | programterv elkészítése |  | 10d | 2009-05-21 | 2009-06-04 | 12, 16, 13FF+2.5% | 0d |  |  | Hermencz Béla; Á programozó 2; Á programozó 3 | 240h | 1,080,000 | 480 | 10 n |
| 18 | S2-2008-TVS.kptv | terv kész | milestone | 0h | 2009-06-04 | 2009-06-04 | 14, 17 | 0d |  |  |  |  |  | 480 | --mérföldkő-- |
| 19 | S2-2008-TVS.mvig | megrendelés visszaigazolása | milestone | 0d | 2009-05-29 | 2009-05-29 |  | 0d |  | must finish on 2009-05-29 |  |  |  | 480 | --mérföldkő-- |
| 20 | S2-2008-TSY | **kódolás** |  | 26d | 2009-05-27 | 2009-07-02 |  | 0d |  |  |  | 304h | 1,368,000 | 480 | 26 n |
| 21 | S2-2008-TSY.áptv | programterv átvétele | milestone | 0h | 2009-06-04 | 2009-06-04 | 18, 19 | 0d |  |  |  |  |  | 480 | --mérföldkő-- |
| 22 | S2-2008-TSY.fabs | adatbázis felállítása |  | 2d | 2009-05-27 | 2009-05-29 | 13 | 4d |  |  | Á adatbázistervező 1; Á adatbázistervező 2 | 32h | 144,000 | 480 | 2 n |
| 23 | S2-2008-TSY.kó1m | 1. modul kódolása |  | 8d | 2009-06-04 | 2009-06-16 | 22, 21 | 2d | 0d |  | Hermencz Béla | 64h | 288,000 | 480 | 8 n |
| 24 | S2-2008-TSY.kó2m | 2. modul kódolása |  | 10d | 2009-06-04 | 2009-06-18 | 21, 22 | 0d |  |  | Á programozó 2 | 80h | 360,000 | 480 | 10 n |
| 25 | S2-2008-TSY.kó3m | 3. modul kódolása |  | 6d | 2009-06-04 | 2009-06-12 | 21, 22 | 4d | 0d |  | Á programozó 3 | 48h | 216,000 | 480 | 6 n |
| 26 | S2-2008-TSY.kófm | főmodul kódolása |  | 10d | 2009-06-18 | 2009-07-02 | 23, 24, 25 | 0d |  |  | Hermencz Béla | 80h | 360,000 | 480 | 10 n |
| 27 | S2-2008-TSY.kkód | kódolás kész | milestone | 0d | 2009-07-02 | 2009-07-02 | 26 | 0d |  |  |  |  |  | 480 | --mérföldkő-- |

| ID | WBS | Task | Type | Duration | Start | Finish | Predecessors | Total slack | Free slack | Constraint | Deadline | Resources | Work | Cost | Text29 | Text30 |
| --- | --- | --- | --- | --- | --- | --- | --- | --- | --- | --- | --- | --- | --- | --- | --- | --- |
| 28 | S2-2008-TTA | **tesztelés** |  | 66d | 2009-04-15 | 2009-07-16 |  | 33.5d |  |  |  |  | 1064h | 2,148,000 | 480 | 66 n |
| 29 | S2-2008-TTA.jkab | javaslatok kidolgozása |  | 1d | 2009-04-15 | 2009-04-16 |  | 98.5d |  |  |  | Á adatbázistervező 1 | 8h | 36,000 | 480 | 1 n |
| 30 | S2-2008-TTA.ts1m | 1. modul tesztelése |  | 10d | 2009-06-16 | 2009-06-30 | 23 | 2d | 0d |  |  | Á adminisztrátor 1; Á adminisztrátor 2; Á műszaki informatikus 1 | 240h | 480,000 | 480 | 10 n |
| 31 | S2-2008-TTA.ts2m | 2. modul tesztelése |  | 8d | 2009-06-18 | 2009-06-30 | 24 | 2d | 0d |  |  | Á adminisztrátor 3; Á adminisztrátor 4; Á műszaki informatikus 2 | 192h | 384,000 | 480 | 8 n |
| 32 | S2-2008-TTA.ts3m | 3. modul tesztelése |  | 6d | 2009-06-12 | 2009-06-22 | 25 | 8d | 0d |  |  | Á adminisztrátor 1; Á adminisztrátor 2; Á műszaki informatikus 1 | 144h | 288,000 | 480 | 6 n |
| 33 | S2-2008-TTA.ktrm | részmodultesztelés kész | milestone | 0d | 2009-06-30 | 2009-06-30 | 30, 31, 32 | 2d |  |  |  |  |  |  | 480 | --mérföldkő-- |
| 34 | S2-2008-TTA.tsfm | főmodul tesztelése |  | 10d | 2009-07-02 | 2009-07-16 | 33, 27 | 0d |  |  |  | Á adminisztrátor 1; Á adminisztrátor 2; Á adminisztrátor 3; Á adminisztrátor 4; Á műszaki informatikus 1; Á műszaki informatikus 2 | 480h | 960,000 | 480 | 10 n |
| 35 | S2-2008-TTA.ksts | tesztelés kész | milestone | 0d | 2009-07-16 | 2009-07-16 | 34 | 33.5d |  |  |  |  |  |  | 480 | --mérföldkő-- |
| 36 | S2-2008-TTB | **kódpontosítás** |  | 21d | 2009-06-22 | 2009-07-21 |  | 0d |  |  |  |  | 72h | 324,000 | 480 | 21 n |
| 37 | S2-2008-TTB.kp1m | 1. modul kódpontosítás |  | 2d | 2009-06-30 | 2009-07-02 | 30 | 13d |  |  |  | Hermencz Béla | 16h | 72,000 | 480 | 2 n |
| 38 | S2-2008-TTB.kp2m | 2. modul kódpontosítás |  | 2d | 2009-06-30 | 2009-07-02 | 31 | 13d |  |  |  | Á programozó 2 | 16h | 72,000 | 480 | 2 n |
| 39 | S2-2008-TTB.kp3m | 3. modul kódpontosítás |  | 2d | 2009-06-22 | 2009-06-24 | 32 | 19d |  |  |  | Á programozó 3 | 16h | 72,000 | 480 | 2 n |
| 40 | S2-2008-TTB.kpfm | főmodul kódpontosítás |  | 3d | 2009-07-16 | 2009-07-21 | 34 | 0d |  |  |  | Hermencz Béla | 24h | 108,000 | 480 | 3 n |
| 41 | S2-2008-TTB.kskp | kódpontosítás kész | milestone | 0d | 2009-07-21 | 2009-07-21 | 37, 38, 39, 40 | 0d |  |  | 2009-07-24 |  |  |  | 480 | --mérföldkő-- |
| 42 | S2-2008-TTH | **Szoftver bevezetése** |  | 30.5d | 2009-07-21 | 2009-09-01 |  | 0d |  |  |  |  | 12h | 44,000 | 480 | 30 n, 4 ó |
| 43 | S2-2008-TTH.bmer | eredmények bemutatása |  | 4h | 2009-07-21 | 2009-07-21 | 41 | 0d |  |  |  | Hermencz Béla; Á adatbázistervező 1; Á műszaki informatikus 1 | 12h | 44,000 | 480 | 4 ó |
| 44 | S2-2008-TTH.dtvl | döntés a továbblépésről | milestone | 0d | 2009-07-22 | 2009-07-22 |  | 0d |  | as late as possible |  |  |  |  | 480 | --mérföldkő-- |
| 45 | S2-2008-TTH.bvsz | szoftver bevezetése |  | 30d | 2009-07-22 | 2009-09-01 | 43, 44 | 0d |  |  |  |  |  |  | 480 | 30 n |
