# Projekt_jo_02_03

Schedule from MS Project, 2008-10-27 to 2008-12-29, status date 2008-11-21, costs in Ft, A marks actual dates.
iqjb

## Calendars

- Szabványos: Mon-Fri 08:00-12:00, 13:00-17:00; Sat-Sun off.

## Resources

| Resource | Unit | Rate |
| --- | --- | --- |
| Á hálózatépítő 1 |  | 1500 |
| Á műszaki informatikus 1 |  | 1500 |
| Á adminisztrátor 1 |  | 1000 |
| Kovács Anita |  | 6000 |
| Kiss Attila |  | 10000 |
| Nagy Annamária |  | 1200 |
| Paál Anikó |  | 1300 |
| Kiss Anett |  | 800 |
| Rétlaki Géza |  | 1400 |
| Mároki Teréz |  | 1400 |
| Mosolygó Ferenc |  | 1600 |
| Téglás Csaba |  | 1200 |
| Podorek Paula |  | 800 |
| Tiefenghalter Eszter |  | 1200 |
| Szakócza István |  | 1700 |
| Késmárki Lilla |  | 1500 |
| Á hálózatépítő 2 |  | 1500 |
| Á műszaki informatikus 2 |  | 1500 |
| Á adminisztrátor 2 |  | 1000 |
| Á műszaki informatikus 3 |  | 1500 |
| Á adminisztrátor 3 |  | 1000 |
| Á adminisztrátor 4 |  | 1000 |
| Számítógép beszerzési költségek | eFt | 1000 |
| Hálózatépítés költségei | eFt | 1000 |
| Egyéb költségek | eFt | 1000 |
| Szoftverköltségek | eFt | 1000 |
| Á programozó 1 |  |  |
| Á programozó 2 |  |  |
| Á_projektmenedzser |  | 6000 |
| Á oktató 1 |  | 4000 |
| Á oktató 2 |  | 4000 |
| Á oktató 3 |  | 4000 |
| Á műszaki informatikus 4 |  | 1500 |
| Kő Pál |  | 1200 |
| Kiss Irén |  | 1200 |
| Nagy Armand |  | 1200 |
| Beke Botond |  | 1200 |
| Kőváry Laura |  | 1200 |
| Kőpataki Tihamér |  | 2100 |
| Baumgartner Karina |  |  |
| Mathiugasz Gitisz |  | 6000 |
| László Róbert |  | 5000 |

## Schedule

| ID | WBS | Task | Type | Duration | Start | Finish | Predecessors | Complete | Remaining | Baseline start | Baseline finish | Baseline duration | Total slack | Free slack | Constraint | Deadline | Resources | Work | Actual work | Cost | Baseline cost | Actual cost | Text29 | Text30 | Text2 |
| --- | --- | --- | --- | --- | --- | --- | --- | --- | --- | --- | --- | --- | --- | --- | --- | --- | --- | --- | --- | --- | --- | --- | --- | --- | --- |
| 1 | 1 | Célmeghatározás |  | 6.5d | 2008-10-27 A | 2008-11-04 A |  | 100% |  | 2008-10-27 | 2008-11-04 | 6.5d |  |  |  |  |  |  |  |  |  |  | 480 | 6 n, 4 ó |  |
| 2 | 2 | Hálózatfejlesztés |  | 9d | 2008-11-04 A | 2008-11-17 A | 1 | 100% |  | 2008-11-04 | 2008-11-17 | 9d |  |  |  |  |  |  |  |  |  |  | 480 | 9 n |  |
| 3 | 3 | **Betanítás** |  | 26.62d? | 2008-11-12 A | 2008-12-19 |  | 11% | 23.75d? | 2008-11-12 | 2008-12-11 | 21d? | 6.76d |  |  |  |  | 344h | 80h | 1,386,000 | 1,296,000 | 282,000 | 480 | 26 n, 5 ó |  |
| 4 | 3.1 | **oktatók felkészítése** |  | 18.62d? | 2008-11-12 A | 2008-12-09 |  | 21% | 14.7d? | 2008-11-12 | 2008-12-01 | 13d? | -1.12d | 0d |  |  |  | 200h | 80h | 810,000 | 720,000 | 282,000 | 480 | 18 n, 5 ó |  |
| 5 | 3.1.1 | oktatók betanítása |  | 4d | 2008-11-12 A | 2008-11-18 A | 2SS+6d | 100% |  | 2008-11-12 | 2008-11-18 | 4d |  |  |  |  | Á oktató 1 [62.5%]; Á oktató 2 [62.5%]; Á oktató 3 [62.5%]; Kőpataki Tihamér [62.5%] | 80h | 80h | 282,000 | 192,000 | 282,000 | 480 | 4 n | Győr |
| 6 | 3.1.2 | Program tesztelése |  | 6d | 2008-11-24 | 2008-12-02 | 5SS+1d |  |  | 2008-11-13 | 2008-11-21 | 6d | -1.12d | 0d | start no earlier than 2008-11-24 |  | László Róbert; Á oktató 1 [50%]; Á oktató 2 [50%]; Á oktató 3 [50%] | 120h |  | 528,000 | 528,000 |  | 480 | 6 n | Győr |
| 7 | 3.1.3 | Látszat | milestone | 0d | 2008-12-03 | 2008-12-03 | 6FF+1d |  |  | 2008-11-24 | 2008-11-24 | 0d | 1.88d |  | start no earlier than 2008-11-24 |  |  |  |  |  |  |  | 480 | --mérföldkő-- | Győr |
| 8 | 3.1.4 | Jegyzet készítése |  | 8d | 2008-11-26 | 2008-12-08 | 6SS+2d, 7FF, 5 |  |  | 2008-11-18 | 2008-11-28 | 8d | -1.12d | 0d | start no earlier than 2008-11-24 |  |  |  |  |  |  |  | 480 | 8 n | Győr |
| 9 | 3.1.5 | Felkészítés kész | milestone | 1d? | 2008-12-08 | 2008-12-09 | 8 |  |  | 2008-11-28 | 2008-12-01 | 1d? | -1.12d | 0d | start no earlier than 2008-11-24 | 2008-12-05 |  |  |  |  |  |  | 480 | --mérföldkő-- |  |
| 10 | 3.2 | **Minőségbiztosítás részleg betanítása** |  | 8d | 2008-12-09 | 2008-12-19 |  |  |  | 2008-12-01 | 2008-12-11 | 8d | 0d |  |  |  |  | 112h |  | 448,000 | 448,000 |  | 480 | 8 n |  |
| 11 | 3.2.1 | csoport 1. |  | 2d | 2008-12-09 | 2008-12-11 | 2, 9 |  |  | 2008-12-01 | 2008-12-03 | 2d | 0d |  | start no earlier than 2008-11-24 |  | Á oktató 1 | 16h |  | 64,000 | 64,000 |  | 480 | 2 n | Győr |
| 12 | 3.2.2 | csoport 2. |  | 3d | 2008-12-11 | 2008-12-16 | 11 |  |  | 2008-12-03 | 2008-12-08 | 3d | 6.76d | 0d | start no earlier than 2008-11-24 |  | Á oktató 1 | 24h |  | 96,000 | 96,000 |  | 480 | 3 n | Győr |
| 13 | 3.2.3 | csoport 3. |  | 3d | 2008-12-16 | 2008-12-19 | 12 |  |  | 2008-12-08 | 2008-12-11 | 3d | 6.76d | 0d | start no earlier than 2008-11-24 |  | Á oktató 1 | 24h |  | 96,000 | 96,000 |  | 480 | 3 n | Győr |
| 14 | 3.2.4 | csoport 1. |  | 3d | 2008-12-11 | 2008-12-16 | 11 |  |  | 2008-12-03 | 2008-12-08 | 3d | 0d |  | start no earlier than 2008-11-24 |  | Á oktató 2 | 24h |  | 96,000 | 96,000 |  | 480 | 3 n | Pécs |
| 15 | 3.2.5 | csoport 2. |  | 3d | 2008-12-16 | 2008-12-19 | 14 |  |  | 2008-12-08 | 2008-12-11 | 3d | 6.76d | 0d | start no earlier than 2008-11-24 |  | Á oktató 2 | 24h |  | 96,000 | 96,000 |  | 480 | 3 n | Pécs |
| 16 | 3.3 | **Karbantartási részleg betanítása** |  | 2d | 2008-12-09 | 2008-12-11 |  |  |  | 2008-12-01 | 2008-12-03 | 2d | 6.76d |  |  |  |  | 32h |  | 128,000 | 128,000 |  | 480 | 2 n |  |
| 17 | 3.3.1 | csoport 1. |  | 2d | 2008-12-09 | 2008-12-11 | 11SS |  |  | 2008-12-01 | 2008-12-03 | 2d | 6.76d | 0d | start no earlier than 2008-11-24 |  | Á oktató 3 | 16h |  | 64,000 | 64,000 |  | 480 | 2 n | Győr |
| 18 | 3.3.2 | csoport 1. |  | 2d | 2008-12-09 | 2008-12-11 | 11SS |  |  | 2008-12-01 | 2008-12-03 | 2d | 6.76d | 0d | start no earlier than 2008-11-24 |  | Á oktató 2 | 16h |  | 64,000 | 64,000 |  | 480 | 2 n | Pécs |
| 19 | 4 | **Adatfeltöltés** |  | 14.76d | 2008-12-09 | 2008-12-29 |  |  |  | 2008-12-01 | 2008-12-22 | 14.76d | 0d |  |  |  |  | 592h |  | 816,000.67 | 816,000.67 |  | 480 | 14 n, 6,05 ó |  |
| 20 | 4.1 | **Minőségbiztosítási részleg adatfeltöltés** |  | 14.76d | 2008-12-09 | 2008-12-29 |  |  |  | 2008-12-01 | 2008-12-22 | 14.76d | 0d |  |  |  |  | 352h |  | 528,000.67 | 528,000.67 |  | 480 | 14 n, 6,05 ó |  |
| 21 | 4.1.1 | adatfeltöltés |  | 12d | 2008-12-09 | 2008-12-25 | 11SS, 13FF-3d |  |  | 2008-12-01 | 2008-12-17 | 12d | 2.76d |  |  |  | Á műszaki informatikus 1; Á műszaki informatikus 2 | 192h |  | 288,000 | 288,000 |  | 480 | 12 n | Győr |
| 22 | 4.1.2 | adatfeltöltés |  | 9.76d | 2008-12-16 | 2008-12-29 | 14, 15FF-2d |  |  | 2008-12-08 | 2008-12-22 | 9.76d | 0d |  |  |  | Á műszaki informatikus 3 [200%]; Á műszaki informatikus 4 | 160h |  | 240,000.67 | 240,000.67 |  | 480 | 9 n, 6,05 ó | Pécs |
| 23 | 4.2 | **Karbantartási részleg adatfeltöltés** |  | 12.76d | 2008-12-11 | 2008-12-29 |  |  |  | 2008-12-03 | 2008-12-22 | 12.76d | 0d |  |  |  |  | 240h |  | 288,000 | 288,000 |  | 480 | 12 n, 6,05 ó |  |
| 24 | 4.2.1 | adatfeltöltés |  | 6d | 2008-12-11 | 2008-12-19 | 17 |  |  | 2008-12-03 | 2008-12-11 | 6d | 6.76d |  |  |  | Beke Botond; Kiss Irén; Kő Pál | 144h |  | 172,800 | 172,800 |  | 480 | 6 n | Győr |
| 25 | 4.2.2 | adatfeltöltés |  | 6d | 2008-12-11 | 2008-12-19 | 18 |  |  | 2008-12-03 | 2008-12-11 | 6d | 6.76d |  |  |  | Kőváry Laura; Nagy Armand | 96h |  | 115,200 | 115,200 |  | 480 | 6 n | Pécs |
| 26 | 4.2.3 | adatfeltöltés kész | milestone | 0d | 2008-12-29 | 2008-12-29 | 21, 22, 24, 25 |  |  | 2008-12-22 | 2008-12-22 | 0d | 0d |  |  |  |  |  |  |  |  |  | 480 | --mérföldkő-- |  |
